# 潮州供水

Schedule from MS Project, 2002-06-15 to 2005-03-31.
水电八局

## Calendars

- 标准: Mon-Fri 08:00-12:00, 13:00-17:00; Sat-Sun off. Exceptions (off unless hours are given): 2002-06-15 to 2002-06-16 08:00-12:00, 13:00-17:00, 2002-06-22 to 2002-06-23 08:00-12:00, 13:00-17:00, 2002-06-29 to 2002-06-30 08:00-12:00, 13:00-17:00, 2002-07-06 to 2002-07-07 08:00-12:00, 13:00-17:00, 2002-07-13 to 2002-07-14 08:00-12:00, 13:00-17:00, 2002-07-20 to 2002-07-21 08:00-12:00, 13:00-17:00, 2002-07-27 to 2002-07-28 08:00-12:00, 13:00-17:00, 2002-07-31 08:00-12:00, 13:00-17:00, 2002-08-03 to 2002-08-04 08:00-12:00, 13:00-17:00, 2002-08-10 to 2002-08-11 08:00-12:00, 13:00-17:00, 2002-08-17 to 2002-08-18 08:00-12:00, 13:00-17:00, 2002-08-22 08:00-12:00, 13:00-17:00, 2002-08-24 to 2002-08-25 08:00-12:00, 13:00-17:00, 2002-08-31 to 2002-09-01 08:00-12:00, 13:00-17:00, 2002-09-07 to 2002-09-08 08:00-12:00, 13:00-17:00, 2002-09-14 to 2002-09-15 08:00-12:00, 13:00-17:00, 2002-09-21 to 2002-09-22 08:00-12:00, 13:00-17:00, 2002-09-28 to 2002-09-29 08:00-12:00, 13:00-17:00, 2002-10-05 to 2002-10-06 08:00-12:00, 13:00-17:00, 2002-10-12 to 2002-10-13 08:00-12:00, 13:00-17:00, 2002-10-19 to 2002-10-20 08:00-12:00, 13:00-17:00, 2002-10-25 to 2002-10-27 08:00-12:00, 13:00-17:00, 2002-11-02 to 2002-11-03 08:00-12:00, 13:00-17:00, 2002-11-09 to 2002-11-10 08:00-12:00, 13:00-17:00, 2002-11-16 to 2002-11-17 08:00-12:00, 13:00-17:00, 2002-11-20 08:00-12:00, 13:00-17:00, 2002-11-23 to 2002-11-24 08:00-12:00, 13:00-17:00, 2002-11-30 to 2002-12-01 08:00-12:00, 13:00-17:00, 2002-12-07 to 2002-12-08 08:00-12:00, 13:00-17:00, 2002-12-14 to 2002-12-15 08:00-12:00, 13:00-17:00, 2002-12-21 to 2002-12-22 08:00-12:00, 13:00-17:00, 2002-12-26 08:00-12:00, 13:00-17:00, 2002-12-28 to 2002-12-29 08:00-12:00, 13:00-17:00, 2003-01-04 to 2003-01-05 08:00-12:00, 13:00-17:00, 2003-01-11 to 2003-01-12 08:00-12:00, 13:00-17:00, 2003-01-18 to 2003-01-19 08:00-12:00, 13:00-17:00, 2003-01-25 to 2003-01-26 08:00-12:00, 13:00-17:00, 2003-02-01 to 2003-02-02 08:00-12:00, 13:00-17:00, 2003-02-08 to 2003-02-09 08:00-12:00, 13:00-17:00, 2003-02-14 to 2003-02-16 08:00-12:00, 13:00-17:00, 2003-02-22 to 2003-02-23 08:00-12:00, 13:00-17:00, 2003-03-01 to 2003-03-02 08:00-12:00, 13:00-17:00, 2003-03-08 to 2003-03-09 08:00-12:00, 13:00-17:00, 2003-03-15 to 2003-03-16 08:00-12:00, 13:00-17:00, 2003-03-20 08:00-12:00, 13:00-17:00, 2003-03-22 to 2003-03-23 08:00-12:00, 13:00-17:00, 2003-03-29 to 2003-03-30 08:00-12:00, 13:00-17:00, 2003-04-05 to 2003-04-06 08:00-12:00, 13:00-17:00, 2003-04-12 to 2003-04-13 08:00-12:00, 13:00-17:00, 2003-04-19 to 2003-04-20 08:00-12:00, 13:00-17:00, 2003-04-25 to 2003-04-27 08:00-12:00, 13:00-17:00, 2003-05-03 to 2003-05-04 08:00-12:00, 13:00-17:00, 2003-05-10 to 2003-05-11 08:00-12:00, 13:00-17:00, 2003-05-17 to 2003-05-18 08:00-12:00, 13:00-17:00, 2003-05-22 08:00-12:00, 13:00-17:00, 2003-05-24 to 2003-05-25 08:00-12:00, 13:00-17:00, 2003-05-31 to 2003-06-01 08:00-12:00, 13:00-17:00, 2003-06-07 to 2003-06-08 08:00-12:00, 13:00-17:00, 2003-06-14 to 2003-06-15 08:00-12:00, 13:00-17:00, 2003-06-19 08:00-12:00, 13:00-17:00, 2003-06-21 to 2003-06-22 08:00-12:00, 13:00-17:00, 2003-06-28 to 2003-06-29 08:00-12:00, 13:00-17:00, 2003-07-05 to 2003-07-06 08:00-12:00, 13:00-17:00, 2003-07-12 to 2003-07-13 08:00-12:00, 13:00-17:00, 2003-07-19 to 2003-07-20 08:00-12:00, 13:00-17:00, 2003-07-25 to 2003-07-27 08:00-12:00, 13:00-17:00, 2003-08-02 to 2003-08-03 08:00-12:00, 13:00-17:00, 2003-08-09 to 2003-08-10 08:00-12:00, 13:00-17:00, 2003-08-16 to 2003-08-17 08:00-12:00, 13:00-17:00, 2003-08-22 to 2003-08-24 08:00-12:00, 13:00-17:00, 2003-08-30 to 2003-08-31 08:00-12:00, 13:00-17:00, 2003-09-06 to 2003-09-07 08:00-12:00, 13:00-17:00, 2003-09-13 to 2003-09-14 08:00-12:00, 13:00-17:00, 2003-09-20 to 2003-09-21 08:00-12:00, 13:00-17:00, 2003-09-27 to 2003-09-28 08:00-12:00, 13:00-17:00, 2003-09-30 08:00-12:00, 13:00-17:00, 2003-10-04 to 2003-10-05 08:00-12:00, 13:00-17:00, 2003-10-11 to 2003-10-12 08:00-12:00, 13:00-17:00, 2003-10-18 to 2003-10-19 08:00-12:00, 13:00-17:00, 2003-10-24 to 2003-10-26 08:00-12:00, 13:00-17:00, 2003-11-01 to 2003-11-02 08:00-12:00, 13:00-17:00, 2003-11-08 to 2003-11-09 08:00-12:00, 13:00-17:00, 2003-11-15 to 2003-11-16 08:00-12:00, 13:00-17:00, 2003-11-22 to 2003-11-23 08:00-12:00, 13:00-17:00, 2003-11-29 to 2003-11-30 08:00-12:00, 13:00-17:00, 2003-12-06 to 2003-12-07 08:00-12:00, 13:00-17:00, 2003-12-12 to 2003-12-14 08:00-12:00, 13:00-17:00, 2003-12-20 to 2003-12-21 08:00-12:00, 13:00-17:00, 2003-12-27 to 2003-12-28 08:00-12:00, 13:00-17:00, 2004-01-03 to 2004-01-04 08:00-12:00, 13:00-17:00, 2004-01-10 to 2004-01-11 08:00-12:00, 13:00-17:00, 2004-01-17 to 2004-01-18 08:00-12:00, 13:00-17:00, 2004-01-24 to 2004-01-25 08:00-12:00, 13:00-17:00, 2004-01-31 to 2004-02-01 08:00-12:00, 13:00-17:00, 2004-02-07 to 2004-02-08 08:00-12:00, 13:00-17:00, 2004-02-13 to 2004-02-15 08:00-12:00, 13:00-17:00, 2004-02-21 to 2004-02-22 08:00-12:00, 13:00-17:00, 2004-02-28 to 2004-02-29 08:00-12:00, 13:00-17:00, 2004-03-06 to 2004-03-07 08:00-12:00, 13:00-17:00, 2004-03-13 to 2004-03-15 08:00-12:00, 13:00-17:00, 2004-03-20 to 2004-03-21 08:00-12:00, 13:00-17:00, 2004-03-27 to 2004-03-28 08:00-12:00, 13:00-17:00, 2004-04-03 to 2004-04-04 08:00-12:00, 13:00-17:00, 2004-04-10 to 2004-04-11 08:00-12:00, 13:00-17:00, 2004-04-17 to 2004-04-18 08:00-12:00, 13:00-17:00, 2004-04-24 to 2004-04-25 08:00-12:00, 13:00-17:00, 2004-05-01 to 2004-05-02 08:00-12:00, 13:00-17:00, 2004-05-08 to 2004-05-09 08:00-12:00, 13:00-17:00, 2004-05-15 to 2004-05-16 08:00-12:00, 13:00-17:00, 2004-05-22 to 2004-05-23 08:00-12:00, 13:00-17:00, 2004-05-29 to 2004-05-30 08:00-12:00, 13:00-17:00, 2004-06-05 to 2004-06-06 08:00-12:00, 13:00-17:00, 2004-06-12 to 2004-06-13 08:00-12:00, 13:00-17:00, 2004-06-19 to 2004-06-20 08:00-12:00, 13:00-17:00, 2004-06-26 to 2004-06-27 08:00-12:00, 13:00-17:00, 2004-07-03 to 2004-07-04 08:00-12:00, 13:00-17:00, 2004-07-10 to 2004-07-11 08:00-12:00, 13:00-17:00, 2004-07-17 to 2004-07-18 08:00-12:00, 13:00-17:00, 2004-07-24 to 2004-07-25 08:00-12:00, 13:00-17:00, 2004-07-31 to 2004-08-01 08:00-12:00, 13:00-17:00, 2004-08-07 to 2004-08-08 08:00-12:00, 13:00-17:00, 2004-08-14 to 2004-08-15 08:00-12:00, 13:00-17:00, 2004-08-21 to 2004-08-22 08:00-12:00, 13:00-17:00, 2004-08-28 to 2004-08-29 08:00-12:00, 13:00-17:00, 2004-08-31 08:00-12:00, 13:00-17:00, 2004-09-04 to 2004-09-05 08:00-12:00, 13:00-17:00, 2004-09-11 to 2004-09-12 08:00-12:00, 13:00-17:00, 2004-09-18 to 2004-09-19 08:00-12:00, 13:00-17:00, 2004-09-25 to 2004-09-26 08:00-12:00, 13:00-17:00, 2004-10-02 to 2004-10-03 08:00-12:00, 13:00-17:00, 2004-10-09 to 2004-10-10 08:00-12:00, 13:00-17:00, 2004-10-16 to 2004-10-17 08:00-12:00, 13:00-17:00, 2004-10-23 to 2004-10-24 08:00-12:00, 13:00-17:00, 2004-10-30 to 2004-10-31 08:00-12:00, 13:00-17:00, 2004-11-06 to 2004-11-07 08:00-12:00, 13:00-17:00, 2004-11-13 to 2004-11-14 08:00-12:00, 13:00-17:00, 2004-11-20 to 2004-11-21 08:00-12:00, 13:00-17:00, 2004-11-27 to 2004-11-28 08:00-12:00, 13:00-17:00, 2004-12-04 to 2004-12-05 08:00-12:00, 13:00-17:00, 2004-12-11 to 2004-12-12 08:00-12:00, 13:00-17:00, 2004-12-18 to 2004-12-19 08:00-12:00, 13:00-17:00, 2004-12-25 to 2004-12-26 08:00-12:00, 13:00-17:00, 2005-01-01 to 2005-01-02 08:00-12:00, 13:00-17:00, 2005-01-08 to 2005-01-09 08:00-12:00, 13:00-17:00, 2005-01-15 to 2005-01-16 08:00-12:00, 13:00-17:00, 2005-01-22 to 2005-01-23 08:00-12:00, 13:00-17:00, 2005-01-29 to 2005-01-30 08:00-12:00, 13:00-17:00, 2005-02-05 to 2005-02-06 08:00-12:00, 13:00-17:00, 2005-02-12 to 2005-02-13 08:00-12:00, 13:00-17:00, 2005-02-19 to 2005-02-20 08:00-12:00, 13:00-17:00, 2005-02-26 to 2005-02-27 08:00-12:00, 13:00-17:00, 2005-03-05 to 2005-03-06 08:00-12:00, 13:00-17:00, 2005-03-12 to 2005-03-13 08:00-12:00, 13:00-17:00, 2005-03-19 to 2005-03-20 08:00-12:00, 13:00-17:00, 2005-03-26 to 2005-03-27 08:00-12:00, 13:00-17:00.

## Resources

| Resource | Unit |
| --- | --- |
| 截流抛投料 | m3 |
| 围堰填料 | m3 |
| 围堰拆除 | m3 |

## Schedule

| ID | WBS | Task | Type | Duration | Start | Finish | Predecessors | Total slack | Free slack | Constraint | Resources | Text2 | Text1 |
| --- | --- | --- | --- | --- | --- | --- | --- | --- | --- | --- | --- | --- | --- |
| 1 | 1 | 工程开工 | milestone | 1d | 2002-06-15 | 2002-06-15 |  | 0d |  | must start on 2002-06-15 |  |  |  |
| 2 | 2 | **施工准备** |  | 45d | 2002-06-16 | 2002-07-30 |  | 975d |  |  |  |  |  |
| 3 | 2.1 | 护堤公路扩建 |  | 45d | 2002-06-16 | 2002-07-30 | 1 | 975d |  | finish no earlier than 2002-07-30 |  | 418 |  |
| 4 | 2.2 | 其他临建工程 |  | 45d | 2002-06-16 | 2002-07-30 | 1 | 975d |  | finish no earlier than 2002-07-30 |  |  |  |
| 5 | 3 | 石料场开采 |  | 1009d | 2002-06-21 | 2005-03-25 | 1 | 6d |  | finish no earlier than 2005-03-25 |  |  |  |
| 6 | 4 | 西溪供水明渠施工 |  | 70d | 2002-08-02 | 2002-10-10 | 1 | 0d |  | finish no earlier than 2002-10-10 |  |  |  |
| 7 | 5 | 安揭引韩下游雍水坝 |  | 31d | 2002-09-10 | 2002-10-10 | 6FF | 0d |  | must finish on 2002-10-10 |  |  |  |
| 8 | 6 | **西溪围堰工程** |  | 304d | 2002-07-01 | 2003-04-30 |  | -2d | 0d |  |  |  |  |
| 9 | 6.1 | **截流工程** |  | 102d | 2002-07-01 | 2002-10-10 |  | -2d | 0d |  |  |  |  |
| 10 | 6.1.1 | 截流备料 |  | 82d | 2002-07-01 | 2002-09-20 |  | -2d | 0d | finish no earlier than 2002-09-20 |  |  |  |
| 11 | 6.1.2 | 护底土工布铺设 |  | 45d | 2002-07-01 | 2002-08-14 |  | 960d | 27d | finish no earlier than 2002-08-14 |  | 23500 | m2 |
| 12 | 6.1.3 | 护底石渣铺设 |  | 63d | 2002-07-10 | 2002-09-10 | 11FF | 933d |  | finish no earlier than 2002-09-10 | 截流抛投料 [16770 m3] | 16770 | m3 |
| 13 | 6.1.4 | 抛投石料、砼 |  | 37d | 2002-08-20 | 2002-09-25 |  | 0d |  | finish no earlier than 2002-09-25 | 截流抛投料 [8500 m3] | 8500 | m3 |
| 14 | 6.1.5 | 左岸预进占 |  | 7d | 2002-09-24 | 2002-09-30 | 13FF, 10 | -5d | 0d | finish no earlier than 2002-09-30 | 截流抛投料 [15817 m3] | 15817 | m3 |
| 15 | 6.1.6 | 戗堤工程 |  | 15d | 2002-09-26 | 2002-10-10 | 14 | -5d | 0d | must finish on 2002-10-10 | 截流抛投料 [41510 m3] | 41510 | m3 |
| 16 | 6.2 | 上下游围堰石渣填筑 |  | 5d | 2002-10-11 | 2002-10-15 |  | 857d | 0d | start no earlier than 2002-10-11 | 围堰填料 [8556 m3] | 8556 | m3 |
| 17 | 6.3 | 上下游围堰土方填筑 |  | 44d | 2002-10-13 | 2002-11-25 | 16FS-3d | 857d |  | finish no earlier than 2002-11-25 | 围堰填料 [273039 m3] | 273039 | m3 |
| 18 | 6.4 | 水泥搅拌桩防渗墙 |  | 11d | 2002-10-15 | 2002-10-25 |  | 0d |  | must finish on 2002-10-25 |  | 32520 |  |
| 19 | 6.5 | 粘土心墙 |  | 37d | 2002-10-15 | 2002-11-20 |  | 862d |  | finish no earlier than 2002-11-20 | 围堰填料 [13543 m3] | 13543 | m3 |
| 20 | 6.6 | 上下游围堰迎水面土工布铺设 |  | 37d | 2002-10-20 | 2002-11-25 |  | 5d |  | finish no earlier than 2002-11-25 |  | 36660 | m2 |
| 21 | 6.7 | 抛石护脚/干砌石护坡 |  | 37d | 2002-10-25 | 2002-11-30 | 20FF | 0d |  | must finish on 2002-11-30 |  | 7388/3150 | m3 |
| 22 | 6.8 | 围堰拆除土方/石方 |  | 30d | 2003-04-01 | 2003-04-30 | 23 | 701d |  | finish no earlier than 2003-04-30 | 围堰拆除 [357960 m3] | 281595/76365 | m3 |
| 23 | 6.9 | 基坑排水 |  | 155d | 2002-10-28 | 2003-03-31 | 18 | 701d | 0d | finish no earlier than 2003-03-31 |  |  |  |
| 24 | 7 | 工程竣工 | milestone | 1d | 2005-03-31 | 2005-03-31 |  | 0d |  | must finish on 2005-03-31 |  |  |  |
